# Project Internationalization of Feedback for CompuGlobalHyperMegaNet

Schedule from MS Project, 2009-04-27 to 2009-08-28.

## Calendars

- Standard: Mon-Fri 08:00-12:00, 13:00-17:00; Sat-Sun off.

## Resources

| Resource |
| --- |
| Systems Analyst |
| Systems Engineer |
| Database Administrator |
| Web Site Designer |
| Web Site Programmer |
| Writer |
| Technical Writer |
| Translator |
| Quality Assurance |
| HR Manager |
| Project Manager |
| User |

## Schedule

| ID | WBS | Task | Type | Duration | Start | Finish | Predecessors | Total slack | Free slack | Resources | Work |
| --- | --- | --- | --- | --- | --- | --- | --- | --- | --- | --- | --- |
| 1 | 1 | **Concept** |  | 7.5d | 2009-04-27 | 2009-05-06 |  | 12.5d |  |  | 60h |
| 2 | 1.1 | Evaluate Current Systems |  | 1.5w | 2009-04-27 | 2009-05-06 |  | 12.5d | 0d | Systems Analyst | 60h |
| 3 | 1.2 | Complete Concept | milestone | 0d | 2009-05-06 | 2009-05-06 | 2 | 12.5d | 0d |  |  |
| 4 | 2 | **Define Requirements** |  | 60d | 2009-05-06 | 2009-07-29 |  | 12.5d |  |  | 480h |
| 5 | 2.1 | Establish New Presentation-Layer Standards |  | 2w | 2009-05-06 | 2009-05-20 | 3 | 12.5d | 0d | Systems Analyst | 80h |
| 6 | 2.2 | Establish New Presentation-Layer Standards |  | 1w | 2009-05-20 | 2009-05-27 | 5 | 12.5d | 0d | Systems Analyst | 40h |
| 7 | 2.3 | Method to Determine User's Country of Origin |  | 4w | 2009-05-27 | 2009-06-24 | 6 | 12.5d | 0d | Systems Analyst | 160h |
| 8 | 2.4 | System Inputs and Outputs |  | 1w | 2009-06-24 | 2009-07-01 | 7 | 12.5d | 0d | Systems Analyst | 40h |
| 9 | 2.5 | Translation Service for Help Desk |  | 2w | 2009-07-01 | 2009-07-15 | 8 | 12.5d | 0d | Systems Analyst | 80h |
| 10 | 2.6 | Report Cubes for Manangement |  | 2w | 2009-07-15 | 2009-07-29 | 9 | 12.5d | 0d | Systems Analyst | 80h |
| 11 | 2.7 | Complete Define Requirements | milestone | 0d | 2009-07-29 | 2009-07-29 | 10 | 12.5d | 0d |  |  |
| 12 | 3 | **Web Site Design** |  | 10d | 2009-07-29 | 2009-08-12 |  | 12.5d |  |  | 80h |
| 13 | 3.1 | Prototype Presentation-Layer Interfaces |  | 1w | 2009-07-29 | 2009-08-05 | 11 | 12.5d | 0d | Web Site Designer | 40h |
| 14 | 3.2 | Acceptance of Presentation-Layer Interface |  | 1w | 2009-08-05 | 2009-08-12 | 13 | 12.5d | 0d | User | 40h |
| 15 | 3.3 | Complete Web Site Design | milestone | 0d | 2009-08-12 | 2009-08-12 | 14 | 12.5d |  |  |  |
| 16 | 4 | **Database Architecture** |  | 5d | 2009-07-29 | 2009-08-05 |  | 17.5d |  |  | 40h |
| 17 | 4.1 | Design Database Tables |  | 1w | 2009-07-29 | 2009-08-05 | 11 | 17.5d | 0d | Database Administrator | 40h |
| 18 | 4.2 | Complete Database Architecture | milestone | 0d | 2009-08-05 | 2009-08-05 | 17 | 17.5d |  |  |  |
| 19 | 5 | **Translation Service Design** |  | 5d | 2009-04-27 | 2009-05-01 |  | 0d |  |  | 80h |
| 20 | 5.1 | Determine Needs of Multilingual Personnel |  | 1w | 2009-04-27 | 2009-05-01 |  | 85d |  | Translator | 40h |
| 21 | 5.2 | Design Training for Multilingual Personnel |  | 1w | 2009-04-27 | 2009-05-01 |  | 0d |  | Translator | 40h |
| 22 | 5.3 | Complete Translation Service Design | milestone | 0d | 2009-05-01 | 2009-05-01 | 21 | 0d |  |  |  |
| 23 | 6 | **Web Site / Database Development** |  | 30d | 2009-05-04 | 2009-06-12 |  | 0d |  |  | 560h |
| 24 | 6.1 | Database Size and Unicode Use |  | 2w | 2009-05-04 | 2009-05-15 | 22 | 75d |  | Database Administrator | 80h |
| 25 | 6.2 | Manage Web Site Translation |  | 6w | 2009-05-04 | 2009-06-12 | 22 | 55d |  | Translator | 240h |
| 26 | 6.3 | Manage Web Site Creation / Modification |  | 6w | 2009-05-04 | 2009-06-12 | 22 | 0d |  | Web Site Programmer | 240h |
| 27 | 6.4 | Complete Web Site / Database Development | milestone | 0d | 2009-06-12 | 2009-06-12 | 26 | 0d |  |  |  |

| ID | WBS | Task | Type | Duration | Start | Finish | Predecessors | Total slack | Resources | Work |
| --- | --- | --- | --- | --- | --- | --- | --- | --- | --- | --- |
| 28 | 7 | **Translation Service Development** |  | 30d | 2009-06-15 | 2009-07-24 |  | 0d |  | 480h |
| 29 | 7.1 | Hire Multilingual Personnel |  | 6w | 2009-06-15 | 2009-07-24 | 27 | 25d | HR Manager | 240h |
| 30 | 7.2 | Train Multilingual Personnel |  | 6w | 2009-06-15 | 2009-07-24 | 27 | 0d | Translator | 240h |
| 31 | 7.3 | Complete Translation Service Development | milestone | 0d | 2009-07-24 | 2009-07-24 | 30 | 0d |  |  |
| 32 | 8 | **Implementation** |  | 25d | 2009-07-27 | 2009-08-28 |  | 0d |  | 200h |
| 33 | 8.1 | Promote Designed Web Pages |  | 1w | 2009-07-27 | 2009-07-31 | 31 | 0d | Systems Engineer | 40h |
| 34 | 8.2 | Quality Assurance |  | 1w | 2009-08-03 | 2009-08-07 | 33 | 0d | Quality Assurance | 40h |
| 35 | 8.3 | Receive Final Acceptance |  | 1w | 2009-08-10 | 2009-08-14 | 34 | 0d | User | 40h |
| 36 | 8.4 | Lessons Learned |  | 1w | 2009-08-17 | 2009-08-21 | 35 | 0d | Project Manager | 40h |
| 37 | 8.5 | Reassign Personnel |  | 1w | 2009-08-24 | 2009-08-28 | 36 | 0d | HR Manager | 40h |
| 38 | 9 | **Maintenance and Support** |  | 5d | 2009-07-27 | 2009-07-31 |  | 20d |  | 80h |
| 39 | 9.1 | Gather Feedback Metrics |  | 1w | 2009-07-27 | 2009-07-31 | 31 | 20d | Quality Assurance | 40h |
| 40 | 9.2 | Provide Continuing Maintenance |  | 1w | 2009-07-27 | 2009-07-31 | 31 | 20d | Project Manager | 40h |
